# Rough_Estimate_Development_Schedule_20040130_TRG

Schedule from MS Project, 2003-10-01 to 2005-08-12, costs in $.
University of California

## Calendars

- Standard: Mon-Fri 08:00-12:00, 13:00-17:00; Sat-Sun off.

## Resources

| Resource | Rate |
| --- | --- |
| PM |  |
| LN |  |
| P1 | 100 |
| P2 | 100 |
| P3 | 100 |
| D1 | 100 |
| P4 | 100 |
| P5 | 100 |
| P6 | 100 |
| P7 | 100 |
| D1a | 100 |
| P8 |  |

## Schedule

| ID | WBS | Task | Duration | Start | Finish | Predecessors | Total slack | Free slack | Constraint | Resources | Work | Cost | Text2 | Text1 |
| --- | --- | --- | --- | --- | --- | --- | --- | --- | --- | --- | --- | --- | --- | --- |
| 1 | 1 | **Start-up** | 66d | 2003-10-01 | 2003-12-31 |  | 422d |  |  |  |  |  |  |  |
| 2 | 1.1 | Identify Project Manager & Liason | 43d | 2003-10-01 | 2003-11-30 |  | 445d |  | finish no earlier than 2003-11-30 |  |  |  |  |  |
| 3 | 1.2 | Identify other staff for start | 43d | 2003-11-03 | 2003-12-31 |  | 422d |  | finish no earlier than 2003-12-31 |  |  |  |  |  |
| 5 | 2 | **Architecture/Design** | 80d | 2004-01-05 | 2004-04-23 |  | 340d |  |  |  | 2400h | 240,000 |  |  |
| 6 | 2.1 | Application Code Design | 160h | 2004-01-05 | 2004-01-30 |  | 400d |  |  | P1 | 160h | 16,000 | 160 |  |
| 7 | 2.2 | Database Design | 480h | 2004-01-05 | 2004-03-26 |  | 360d |  |  | P3 | 480h | 48,000 | 480 |  |
| 8 | 2.3 | Presentation Design - Initial | 320h | 2004-01-05 | 2004-02-27 |  | 340d | 0d |  | D1 | 320h | 32,000 | 320 |  |
| 9 | 2.4 | Presentation Design - Revised | 320h | 2004-03-01 | 2004-04-23 | 8 | 340d |  | start no earlier than 2004-03-01 | D1a | 320h | 32,000 | 640 |  |
| 10 | 2.5 | Data Interfaces | 640h | 2004-01-05 | 2004-04-23 |  | 340d |  |  | P1; P2 | 1120h | 112,000 | 640 |  |
| 12 | 3 | **Development** | 355.67d | 2004-03-01 | 2005-07-11 |  | 24.33d |  |  |  | 12224h | 1,174,400 |  |  |
| 13 | 3.1 | **Data Interfaces** | 140d | 2004-04-05 | 2004-10-15 |  | 215d |  |  |  | 1800h | 180,000 |  | Generic interfaces to local campus systems |
| 14 | 3.1.1 | Initial Data Load | 320h | 2004-04-05 | 2004-05-28 |  | 315d |  | start no earlier than 2004-04-05 | P4 | 320h | 32,000 |  |  |
| 15 | 3.1.2 | Payroll/Personnel System (PPS) | 200h | 2004-04-26 | 2004-05-28 |  | 315d |  |  | P2 | 200h | 20,000 | 160 | Payroll Audit Record |
| 16 | 3.1.3 | Financial Systems | 200h | 2004-05-31 | 2004-07-02 |  | 290d |  |  | P2 | 200h | 20,000 | 160 | Account/Fund Profile |
| 17 | 3.1.4 | Contracts & Grants | 200h | 2004-06-21 | 2004-07-23 |  | 275d |  |  | P3 | 200h | 20,000 | 160 |  |
| 18 | 3.1.5 | Cost Sharing | 320h | 2004-07-26 | 2004-09-17 |  | 235d |  |  | P3 | 320h | 32,000 | 160 |  |
| 19 | 3.1.6 | Authentication | 200h | 2004-04-26 | 2004-05-28 |  | 315d |  |  | P1 | 200h | 20,000 | 160 | (Security System) |
| 20 | 3.1.7 | Authorization | 200h | 2004-05-31 | 2004-07-02 |  | 290d |  |  | P1 | 200h | 20,000 | 160 | (Security System) |
| 21 | 3.1.8 | Email | 160h | 2004-09-20 | 2004-10-15 |  | 215d |  |  | P3 | 160h | 16,000 | 160 |  |
| 22 | 3.2 | Web Presentation | 640h | 2004-03-01 | 2004-06-18 |  | 300d |  |  | D1; P3 | 960h | 96,000 | 480 | Detailed page layout, style sheets, graphics |
| 23 | 3.3 | Authorization Rules | 480h | 2004-07-05 | 2004-09-24 |  | 230d |  |  | P1 | 480h | 48,000 | 480 | Implementation of roles and associated permissions |
| 24 | 3.4 | Authorizaton Administration | 480h | 2004-07-05 | 2004-09-24 |  | 230d |  |  | P2 | 480h | 48,000 | 480 | Tool(s) for administration of roles and permissions |
| 25 | 3.5 | Web Navigation | 213.33h | 2004-07-02 | 2004-08-09 |  | 264.33d |  | start no earlier than 2004-07-02 | D1; P5 | 320h | 32,000 | 320 | General web navigation details for ERS |
| 26 | 3.6 | Workflow (Dept-level Review/Release) | 320h | 2004-07-08 | 2004-09-01 |  | 247d |  | finish no earlier than 2004-09-01 | P6 | 320h | 32,000 | 320 | Mechanism for handling step-through flow of effort reports |

| ID | WBS | Task | Duration | Start | Finish | Total slack | Constraint | Resources | Work | Cost | Text2 |
| --- | --- | --- | --- | --- | --- | --- | --- | --- | --- | --- | --- |
| 27 | 3.7 | **Effort Report Generation** | 210d | 2004-07-01 | 2005-04-20 | 82d |  |  | 1200h | 120,000 |  |
| 28 | 3.7.1 | Standard Report | 480h | 2004-07-01 | 2004-09-22 | 232d | start no earlier than 2004-07-01 | P4 | 480h | 48,000 | 480 |
| 29 | 3.7.2 | Exception | 480h | 2004-10-18 | 2005-01-07 | 155d |  | P3 | 480h | 48,000 | 480 |
| 30 | 3.7.3 | Reissuance | 240h | 2005-03-10 | 2005-04-20 | 82d |  | P2 | 240h | 24,000 | 240 |
| 31 | 3.8 | Notifications | 320h | 2004-09-27 | 2004-11-19 | 190d |  | P1 | 320h | 32,000 | 320 |
| 32 | 3.9 | Effort Report Search/Selection | 480h | 2004-08-09 | 2004-11-01 | 204.33d | start no earlier than 2004-07-08 | P5 | 480h | 48,000 | 480 |
| 33 | 3.10 | Online Effort Report Data Changes | 160h | 2005-01-10 | 2005-02-04 | 135d |  | P3 | 160h | 16,000 | 160 |
| 34 | 3.11 | Online Certifications | 160h | 2005-02-07 | 2005-03-04 | 115d |  | P3 | 160h | 16,000 | 160 |
| 35 | 3.12 | Multiple Certifications | 320h | 2005-03-07 | 2005-04-29 | 75d |  | P3 | 320h | 32,000 | 320 |
| 36 | 3.13 | Online Exception Data Collection/Modification | 480h | 2004-11-01 | 2005-01-24 | 144.33d | start no earlier than 2004-07-08 | P5 | 480h | 48,000 | 480 |
| 37 | 3.14 | Edits | 960h | 2004-09-23 | 2005-03-09 | 112d | start no earlier than 2004-07-01 | P2; P4 | 1544h | 154,400 | 1200 |
| 38 | 3.15 | Reminders | 160h | 2005-01-06 | 2005-02-02 | 137d | start no earlier than 2004-09-01 | P4 | 160h | 16,000 | 160 |
| 39 | 3.16 | Compliance Monitoring Tools* | 640h | 2004-11-22 | 2005-03-11 | 110d |  | P1 | 640h | 64,000 | 640 |
| 40 | 3.17 | Control/Audit Reports* | 480h | 2005-03-01 | 2005-05-23 | 59d | start no earlier than 2005-03-01 | P8 | 480h |  | 480 |
| 41 | 3.18 | General Reporting* | 960h | 2005-01-24 | 2005-07-11 | 24.33d | start no earlier than 2004-07-08 | P5 | 960h | 96,000 | 960 |
| 42 | 3.19 | Ad Hoc Reporting* | 960h | 2005-01-03 | 2005-06-17 | 40d | start no earlier than 2005-01-01 | P6 | 960h | 96,000 | 960 |
| 44 | 4 | **Testing** | 119d | 2005-03-01 | 2005-08-12 | 0d |  |  | 1280h | 128,000 |  |
| 45 | 4.1 | Application Testing | 664h | 2005-03-01 | 2005-06-23 | 36d | start no earlier than 2005-03-01 | P7; P4 | 960h | 96,000 | 960 |
| 46 | 4.2 | Load/Stress Testing | 320h | 2005-06-20 | 2005-08-12 | 0d | start no earlier than 2005-04-15 | P6 | 320h | 32,000 | 320 |
| 48 | 5 | **Deployment (Release to Campuses)** | 109d | 2005-03-14 | 2005-08-11 | 1d |  |  | 1120h | 112,000 |  |
| 49 | 5.1 | Documentation | 544h | 2005-03-14 | 2005-06-15 | 42d |  | P2; P1 | 640h | 64,000 | 640 |
| 50 | 5.2 | Web-based User Training Materials (Generic) | 480h | 2005-05-02 | 2005-07-22 | 15d | start no earlier than 2005-05-01 |  |  |  |  |
| 51 | 5.3 | Technical Training | 320h | 2005-05-09 | 2005-07-01 | 30d |  | P1 | 320h | 32,000 | 320 |
| 52 | 5.4 | Deployment (Release) Packaging | 160h | 2005-07-15 | 2005-08-11 | 1d | start no earlier than 2005-07-15 | P3 | 160h | 16,000 | 160 |

Notes:
- 28: Text1: Standard generation (batch and one-time) of the Effort Report
- 29: Text1: Generation of effort reports for previously excluded or terminating employees
- 30: Text1: re-generation of effort reports when changes in effort meet threshhold requirements for re-certification
- 31: Text1: Mechanism for notifying individuals that effort reports are ready for pre-review, review/certification, or have been certified
- 32: Text1: Mechanism for locating effort reports (general search, role-based search, etc.)
- 33: Text1: Mechanism for changing effort detail on an individual effort report
- 34: Text1: Mechanism for certifying one effort report
- 35: Text1: Mechanism for certifying two or more effort reports at one time
- 36: Text1: Mechanism for collecting data on individuals who received no pay from a sponsored project
- 37: Text1: Various edits on data from incoming interface files and data entered online
- 38: Text1: Mechanism for providing reminders of needed reviews and certifications
- 39: Text1: Reports for measuring current period compliance and comparing with historical periods
- 40: Text1: System-level controls and audit reports(e.g., system access reports, transaction statistics)
- 41: Text1: Standard reporting other than compliance/control/audit reporting (needs detailed definition)
- 42: Text1: (if other than third-party tools-based reporting)
- 46: Text1: Stress testing to determine system performance characteristics
- 49: Text1: System Technical Documentation
- 52: Text1: Source Inventories, Installation and Installation Verification Instructions, etc.

| ID | WBS | Task | Duration | Start | Finish | Total slack | Constraint | Resources | Work | Cost | Text2 |
| --- | --- | --- | --- | --- | --- | --- | --- | --- | --- | --- | --- |
| 54 | 6 | **Project Management** | 375d | 2004-01-05 | 2005-06-10 | 11.56d |  |  | 4040h | 404,000 |  |
| 55 | 6.1 | Technical Project Management | 3000h | 2004-01-05 | 2005-06-10 | 45d |  | PM | 3000h | 300,000 | 3000 |
| 56 | 6.2 | Campus Coordination | 1040h | 2004-01-05 | 2005-06-06 | 11.56d | start no earlier than 2004-01-05 | LN | 1040h | 104,000 | 1000 |

Notes:
- 55: Text1: Day-to-day technical project management
- 56: Text1: Coordination of campus staff participating in resolving requirements/development issues, system testing, etc.
